# 4k_CameraProjectTimeline

Schedule from MS Project, 2019-09-03 to 2020-12-28, A marks actual dates.
MBARI

## Calendars

- Standard: Mon-Fri 08:00-12:00, 13:00-17:00; Sat-Sun off.

## Resources

| Resource |
| --- |
| Mark Chaffey |
| Craig Dawe |
| DJ Osborne |
| David French |
| Ben Irwin |
| Machine shop |
| Tech support |
| Andy Hamilton |
| Outside consultant |
| Francois Cazenave |
| Lonny Lundsten |
| Vendor |

## Schedule

| ID | WBS | Task | Type | Duration | Start | Finish | Predecessors | Complete | Remaining | Baseline start | Baseline finish | Baseline duration | Total slack | Free slack | Constraint | Resources | Work | Actual work |
| --- | --- | --- | --- | --- | --- | --- | --- | --- | --- | --- | --- | --- | --- | --- | --- | --- | --- | --- |
| 1 | 1 | Discussions with vendors |  | 20d | 2019-09-05 A | 2019-10-03 A |  | 100% |  | 2019-09-05 | 2019-10-03 | 20d |  |  |  | Mark Chaffey [50%] | 80h | 80h |
| 2 | 2 | Prepare RFP for vendors |  | 14d | 2019-09-03 A | 2019-09-20 A |  | 100% |  | 2019-09-03 | 2019-09-20 | 14d |  |  | finish no earlier than 2019-09-20 | Mark Chaffey | 112h | 112h |
| 3 | 3 | Vendor response time |  | 14d | 2019-09-23 A | 2019-10-10 A | 2, 1FF | 100% |  | 2019-09-23 | 2019-10-10 | 14d |  |  | finish no earlier than 2019-10-10 |  |  |  |
| 4 | 4 | Decision on vendor or in-house |  | 15d | 2019-10-10 A | 2019-10-31 A | 3 | 100% |  | 2019-10-10 | 2019-10-10 |  |  |  | finish no earlier than 2019-10-31 |  |  |  |
| 5 | 5 | Telemetry system preliminary design |  | 5d | 2019-11-04 A | 2019-11-08 A |  | 100% |  | 2019-10-24 | 2019-10-31 | 5d |  |  | start no earlier than 2019-11-02 | Mark Chaffey | 40h | 40h |
| 6 | 6 | Preliminary chassis and fit design |  | 10d | 2019-10-03 A | 2019-10-17 A |  | 100% |  | 2019-10-03 | 2019-10-17 | 10d |  |  |  | Mark Chaffey | 80h | 80h |
| 7 | 7 | Preperation for PDR |  | 9d | 2019-11-01 A | 2019-11-13 A | 4 | 100% |  | 2019-10-11 | 2019-10-31 | 5.25d |  |  |  | Mark Chaffey; Craig Dawe; DJ Osborne; David French; Ben Irwin | 288h | 288h |
| 8 | 8 | Preliminary System Design Review |  | 1d | 2019-11-14 A | 2019-11-14 A | 7, 5, 6 | 100% |  | 2019-11-01 | 2019-11-01 | 0.25d |  |  | finish no earlier than 2019-11-13 | Mark Chaffey; Craig Dawe; DJ Osborne; David French; Ben Irwin | 40h | 40h |
| 9 | 9 | Release PO for camera |  | 1d | 2019-11-15 A | 2019-11-15 A | 8 | 100% |  | 2019-11-01 | 2019-11-04 | 1d |  |  |  | Mark Chaffey | 8h | 8h |
| 10 | 10 | Release PO for camera lens |  | 1d | 2020-01-07 A | 2020-01-07 A | 8 | 100% |  | 2019-11-25 | 2019-11-25 | 1d |  |  | start no earlier than 2020-01-07 | Mark Chaffey | 8h | 8h |
| 11 | 11 | Release PO for telemetry system |  | 1d | 2020-03-09 A | 2020-03-09 A | 8 | 100% |  | 2020-02-24 | 2020-02-24 | 1d |  |  |  | Mark Chaffey | 8h | 8h |
| 12 | 12 | Camera delivery from vendor |  | 40d | 2019-11-18 A | 2020-01-10 A | 9 | 100% |  | 2019-11-04 | 2019-12-30 | 40d |  |  |  |  |  |  |
| 13 | 13 | Lens delivery from vendor |  | 45d | 2020-01-08 A | 2020-03-10 A | 10 | 100% |  | 2019-11-26 | 2020-01-27 | 45d |  |  |  |  |  |  |
| 14 | 14 | Telemetry system delivery from vendor |  | 25d | 2020-03-10 A | 2020-04-13 A | 11 | 100% |  | 2020-02-25 | 2020-03-30 | 25d |  |  |  |  |  |  |
| 15 | 15 | Camera chassis detailed design |  | 136d | 2020-01-13 A | 2020-07-22 | 12 | 95% | 6.8d | 2019-12-30 | 2020-01-27 | 20d | 41.7d | 33.2d | finish no earlier than 2020-07-20 | Mark Chaffey | 1088h | 1033.6h |
| 16 | 16 | Fix housing diameter | milestone | 0d | 2020-02-07 A | 2020-02-07 A | 15 | 100% |  | 2020-01-27 | 2020-01-27 |  |  |  |  | Mark Chaffey |  |  |
| 17 | 17 | Electronic system detailed design |  | 15d | 2020-07-14 | 2020-09-07 | 8 |  |  | 2019-12-26 | 2020-02-13 | 10d | 10d |  | start no earlier than 2020-07-13 | Mark Chaffey | 120h |  |
| 18 | 18 | Control box detailed design |  | 8d | 2020-09-14 | 2020-09-23 | 8 |  |  | 2020-02-13 | 2020-02-21 | 6d | 68d |  | start no earlier than 2020-09-13 | Mark Chaffey | 64h |  |
| 19 | 19 | Cable and connector detailed design |  | 5d | 2020-07-14 | 2020-07-20 | 8 |  |  | 2019-11-26 | 2019-12-03 | 5d | 10d | 0d | start no earlier than 2020-07-13 | Mark Chaffey | 40h |  |
| 20 | 20 | Order bulkhead connectors and cables |  | 2d | 2020-07-21 | 2020-07-22 | 19 |  |  | 2019-12-03 | 2019-12-05 | 2d | 17d | 7d | start no earlier than 2020-07-13 | Mark Chaffey | 16h |  |
| 21 | 21 | Connector delivery from vendor |  | 60d | 2020-08-03 | 2020-10-23 | 20 |  |  | 2019-12-05 | 2020-02-27 | 60d | 10d |  | start no earlier than 2020-08-02 |  |  |  |
| 22 | 22 | Design management PCB |  | 15d | 2020-07-14 | 2020-08-03 | 8 |  |  | 2019-12-05 | 2019-12-26 | 15d | 33.5d | 20d | start no earlier than 2020-07-13 | Mark Chaffey | 120h |  |
| 23 | 23 | Critical design review (CDR) |  | 0.5d | 2020-09-08 | 2020-09-08 | 22, 19, 15, 17 |  |  | 2020-02-21 | 2020-02-21 | 0.5d | 8.5d | 0d |  | Mark Chaffey; Craig Dawe; DJ Osborne; David French; Ben Irwin | 20h |  |
| 24 | 24 | Fabrication of chassis components |  | 35d | 2020-09-21 | 2020-11-06 | 23 |  |  | 2020-06-15 | 2020-07-22 | 28d | 0d |  | start no earlier than 2020-09-20 | Machine shop | 280h |  |
| 25 | 25 | Fabricate management PCB |  | 15d | 2020-09-08 | 2020-09-29 | 23 |  |  | 2020-02-21 | 2020-03-13 | 15d | 64.5d |  | start no earlier than 2019-09-03 | Tech support | 120h |  |
| 26 | 26 | Build lens control testbed |  | 5d | 2020-07-14 | 2020-07-20 | 13 |  |  | 2020-01-28 | 2020-02-03 | 5d | 42d | 0d | start no earlier than 2020-07-13 | Mark Chaffey | 40h |  |
| 27 | 27 | Write camera applications software |  | 35d | 2020-07-21 | 2020-09-07 | 26 |  |  | 2020-02-04 | 2020-03-23 | 35d | 42d |  | start no earlier than 2020-07-13 | Andy Hamilton | 280h |  |
| 28 | 28 | Machine new control box |  | 10d | 2020-09-08 | 2020-09-22 | 23 |  |  | 2020-02-21 | 2020-03-27 | 25d | 31.5d | 0d | start no earlier than 2019-09-03 | Machine shop | 80h |  |
| 29 | 29 | Assemble new control box |  | 7d | 2020-09-22 | 2020-10-01 | 28 |  |  | 2020-03-27 | 2020-04-03 | 5d | 31.5d |  | start no earlier than 2019-09-03 | Mark Chaffey | 56h |  |
| 30 | 30 | Final assembly of camera system in chassis |  | 5d | 2020-11-09 | 2020-11-13 | 21, 24, 14 |  |  | 2020-07-23 | 2020-07-29 | 5d | 0d |  |  | Mark Chaffey | 40h |  |
| 31 | 31 | Test camera system and electronics |  | 10d | 2020-11-16 | 2020-11-27 | 30, 29, 27 |  |  | 2020-07-30 | 2020-08-12 | 10d | 0d |  |  | Mark Chaffey; Andy Hamilton | 160h |  |
| 32 | 32 | Camera system complete | milestone | 0d | 2020-11-27 | 2020-11-27 | 31 |  |  | 2020-08-12 | 2020-08-12 |  | 0d |  |  |  |  |  |

| ID | WBS | Task | Type | Duration | Start | Finish | Predecessors | Complete | Remaining | Baseline start | Baseline finish | Baseline duration | Total slack | Free slack | Constraint | Resources | Work | Actual work |
| --- | --- | --- | --- | --- | --- | --- | --- | --- | --- | --- | --- | --- | --- | --- | --- | --- | --- | --- |
| 33 | 33 | **DSP&L build housing and dome** |  | 251.84d | 2019-12-09 A | 2020-11-24 |  | 26% | 186.89d | 2019-11-25 | 2020-07-20 | 170d | 3.16d |  |  |  | 881.65h | 188h |
| 34 | 33.1 | DSP&L complete final design |  | 31.84d | 2019-12-09 A | 2020-07-28 | 4, 16FF+20d | 95% | 1.71d | 2019-11-25 | 2020-02-24 | 65d | 3.16d | 0d |  | Vendor | 201.65h | 188h |
| 35 | 33.2 | Review DSP&L design |  | 5d | 2020-07-28 | 2020-08-04 | 34 |  |  | 2020-02-24 | 2020-03-02 | 5d | 3.16d | 0d | start no earlier than 2020-07-13 | Mark Chaffey | 40h |  |
| 36 | 33.3 | DSP&L complete housing fabrication and testing |  | 80d | 2020-08-04 | 2020-11-24 | 35 |  |  | 2020-03-02 | 2020-07-20 | 100d | 3.16d |  | start no earlier than 2020-07-13 | Vendor | 640h |  |
| 37 | 34 | **Final Assembly and testing** |  | 21d | 2020-11-30 | 2020-12-28 | 32, 33, 36 |  |  | 2020-08-13 | 2020-09-10 | 21d | 0d |  |  |  | 376h |  |
| 38 | 34.1 | Final assembly of camera and housing |  | 7d | 2020-11-30 | 2020-12-08 |  |  |  | 2020-08-13 | 2020-08-21 | 7d | 0d |  | start no earlier than 2019-09-03 | Mark Chaffey | 56h |  |
| 39 | 34.2 | Test camera optics and control system |  | 10d | 2020-12-09 | 2020-12-22 | 38 |  |  | 2020-08-24 | 2020-09-04 | 10d | 0d |  | start no earlier than 2019-09-03 | Mark Chaffey; Andy Hamilton | 160h |  |
| 40 | 34.3 | End-to-end testing on Carson |  | 2d | 2020-12-23 | 2020-12-24 | 39 |  |  | 2020-09-07 | 2020-09-08 | 2d | 2d |  | start no earlier than 2019-09-03 | Mark Chaffey; Andy Hamilton; Craig Dawe; DJ Osborne; Lonny Lundsten | 80h |  |
| 41 | 34.4 | End-to-end testing on Western Flyer |  | 4d | 2020-12-23 | 2020-12-28 | 39 |  |  | 2020-09-07 | 2020-09-10 | 4d | 0d |  |  | Mark Chaffey; Andy Hamilton; Craig Dawe; Ben Irwin; Lonny Lundsten | 80h |  |
| 42 | 34.5 | Done | milestone | 0d | 2020-12-28 | 2020-12-28 | 41 |  |  |  |  |  | 0d |  |  |  |  |  |
